# Target Hall shedule 131 Sep to Dec

Schedule from MS Project, 2016-08-23 to 2016-12-06, A marks actual dates.

## Calendars

- Standard: Mon-Fri 08:00-12:00, 13:00-17:00; Sat-Sun off.

## Resources

| Resource |
| --- |
| Wang.D |
| Cave.T |
| Fisher.C |
| Mjos.A |
| RPG |
| Target group |
| Mcdonald.D |
| Dalla Valle.M |

## Schedule

| ID | WBS | Task | Duration | Start | Finish | Predecessors | Complete | Total slack | Free slack | Constraint | Resources | Work | Actual work |
| --- | --- | --- | --- | --- | --- | --- | --- | --- | --- | --- | --- | --- | --- |
| 1 | 1 | **TM2 HpTa Ready for ITW** | 11d | 2016-08-23 08:00 A | 2016-09-06 17:00 A |  | 100% |  |  |  |  | 88h | 88h |
| 2 | 1.1 | HpTa Target Insert into SHC | 0.25d | 2016-08-23 08:00 A | 2016-08-23 10:00 A |  | 100% |  |  | start no earlier than 2016-08-23 08:00 | Fisher.C; Mjos.A | 4h | 4h |
| 3 | 1.2 | Module Disconnection-TM2-ITW | 0.25d | 2016-08-23 10:00 A | 2016-08-23 12:00 A | 2 | 100% |  |  | start no earlier than 2016-08-23 08:00 | Wang.D; Mcdonald.D | 4h | 4h |
| 4 | 1.3 | Module Move-TM2-ITW to SHC | 0.25d | 2016-08-23 13:00 A | 2016-08-23 15:00 A | 3 | 100% |  |  | start no earlier than 2016-08-23 08:00 | Cave.T; Wang.D | 4h | 4h |
| 5 | 1.4 | New Target Installation/Electrical Check | 0.5d | 2016-08-24 08:00 A | 2016-08-24 12:00 A | 4 | 100% |  |  | start no earlier than 2016-08-24 08:00 | Cave.T; Fisher.C; Wang.D | 12h | 12h |
| 6 | 1.5 | Module Move-TM2-SHC to CS/Start of Pumps | 0.5d | 2016-08-24 13:00 A | 2016-08-24 17:00 A | 5 | 100% |  |  | start no earlier than 2016-08-24 08:00 | Wang.D | 4h | 4h |
| 7 | 1.6 | Spent Target Move | 1d | 2016-08-25 08:00 A | 2016-08-25 17:00 A | 6 | 100% |  |  | start no earlier than 2016-08-25 08:00 | Cave.T; Wang.D; Fisher.C | 24h | 24h |
| 8 | 1.7 | Module Move-TM2-TCS to ITW | 0.5d | 2016-08-30 08:00 A | 2016-08-30 12:00 A | 7 | 100% |  |  | start no earlier than 2016-08-30 08:00 | Cave.T; Mcdonald.D; Wang.D | 12h | 12h |
| 9 | 1.8 | Module Connection-TM2-ITW/Start of Pumps | 0.5d | 2016-08-30 13:00 A | 2016-08-30 17:00 A | 8 | 100% |  |  | start no earlier than 2016-08-30 08:00 | Mcdonald.D; Wang.D | 8h | 8h |
| 10 | 1.9 | Shielding Blocks Transfer-ITE to ITW | 1d | 2016-09-06 08:00 A | 2016-09-06 17:00 A | 9 | 100% |  |  | start no earlier than 2016-09-06 08:00 | Mcdonald.D; Wang.D | 16h | 16h |
| 11 | 2 | **TM4 LpSiC IGLIS Target Ready for ITE** | 11d | 2016-09-20 08:00 | 2016-10-04 17:00 |  |  | 32.7d |  |  |  | 87.6h |  |
| 12 | 2.1 | Lp SiC Target Insert into SHC | 0.1d | 2016-09-20 08:00 | 2016-09-20 08:48 | 10 |  | 38.85d | 0d | start no earlier than 2016-09-20 08:00 | Fisher.C; Mjos.A | 1.6h |  |
| 13 | 2.2 | Module Disconnection TM4-ITE | 0.25d | 2016-09-20 08:48 | 2016-09-20 10:48 | 12 |  | 38.85d | 0d | start no earlier than 2016-09-20 08:00 | Mcdonald.D; Wang.D | 4h |  |
| 14 | 2.3 | Module Move-TM4-ITE to SHC | 0.25d | 2016-09-20 10:48 | 2016-09-20 13:48 | 13 |  | 38.85d | 0d | start no earlier than 2016-09-20 08:00 | Cave.T; Wang.D | 4h |  |
| 15 | 2.4 | LpSiC Target Installation/Electrical check-SHC | 0.25d | 2016-09-20 13:48 | 2016-09-20 15:48 | 14 |  | 38.85d | 0.15d | start no earlier than 2016-09-20 08:00 | Cave.T; Fisher.C; Wang.D | 6h |  |
| 16 | 2.5 | Module Move-TM4-SHC to CS/Start of Pumps | 1d | 2016-09-21 08:00 | 2016-09-21 17:00 | 15 |  | 38.7d | 0d | start no earlier than 2016-09-21 08:00 | Cave.T; Wang.D | 16h |  |
| 17 | 2.6 | Spent Target Move | 1d | 2016-09-22 08:00 | 2016-09-22 17:00 | 16 |  | 38.7d | 2d | start no earlier than 2016-09-22 08:00 | Cave.T; Fisher.C; Wang.D | 24h |  |
| 18 | 2.7 | Module Move-TM4-TCS to ITE | 0.5d | 2016-09-27 08:00 | 2016-09-27 12:00 | 17 |  | 36.7d | 0d | start no earlier than 2016-09-27 08:00 | Cave.T; Wang.D | 8h |  |
| 19 | 2.8 | Module Connection-TM4-ITW/Start of Pumps | 0.5d | 2016-09-27 13:00 | 2016-09-27 17:00 | 18 |  | 36.7d | 4d | start no earlier than 2016-09-27 08:00 | Mcdonald.D; Wang.D | 8h |  |
| 20 | 2.9 | Shielding Blocks Transfer-ITW to ITE | 1d | 2016-10-04 08:00 | 2016-10-04 17:00 | 19 |  | 32.7d | 4d | start no earlier than 2016-10-04 08:00 | Mcdonald.D; Wang.D | 16h |  |
| 21 | 3 | **TM2 HpSiC FEBIAD Target Ready for ITW** | 11d | 2016-10-11 08:00 | 2016-10-25 17:00 |  |  | 22.45d |  |  |  | 80h |  |
| 22 | 3.1 | HpSiC FEBIAD Target Insert into SHC | 0.25d | 2016-10-11 08:00 | 2016-10-11 10:00 | 20 |  | 28.7d | 0d | start no earlier than 2016-10-11 08:00 | Fisher.C; Mjos.A | 4h |  |
| 23 | 3.2 | Module Disconnection-TM2-ITW | 0.25d | 2016-10-11 10:00 | 2016-10-11 12:00 | 22 |  | 28.7d | 0d | start no earlier than 2016-10-11 08:00 | Mcdonald.D; Wang.D | 4h |  |
| 24 | 3.3 | Module Move-TM2-ITW to SHC | 0.25d | 2016-10-11 13:00 | 2016-10-11 15:00 | 23 |  | 28.7d | 0.25d | start no earlier than 2016-10-11 08:00 | Cave.T; Wang.D | 4h |  |
| 25 | 3.4 | New Target Installation/Electrical Check | 0.5d | 2016-10-12 08:00 | 2016-10-12 12:00 | 24 |  | 28.45d | 0d | start no earlier than 2016-10-12 08:00 | Cave.T; Fisher.C; Wang.D | 12h |  |
| 26 | 3.5 | Module Move-TM2-SHC to CS/Start of Pumps | 0.5d | 2016-10-12 13:00 | 2016-10-12 17:00 | 25 |  | 28.45d | 0d | start no earlier than 2016-10-12 08:00 | Cave.T; Wang.D | 8h |  |
| 27 | 3.6 | Spent Target Move | 1d | 2016-10-13 08:00 | 2016-10-13 17:00 | 26 |  | 28.45d | 2d | start no earlier than 2016-10-13 08:00 | Fisher.C; Cave.T | 16h |  |
| 28 | 3.7 | Module Move-TM2-TCS to ITW | 0.5d | 2016-10-18 08:00 | 2016-10-18 12:00 | 27 |  | 26.45d | 0d | start no earlier than 2016-10-18 08:00 | Cave.T; Wang.D | 8h |  |
| 29 | 3.8 | Module Connection-TM2-ITW/Start of Pumps | 0.5d | 2016-10-18 13:00 | 2016-10-18 17:00 | 28 |  | 26.45d | 4d | start no earlier than 2016-10-18 08:00 | Mcdonald.D; Wang.D | 8h |  |
| 30 | 3.9 | Shielding Blocks Transfer-ITE to ITW | 1d | 2016-10-25 08:00 | 2016-10-25 17:00 | 29 |  | 22.45d | 4d | start no earlier than 2016-10-25 08:00 | Wang.D; Mcdonald.D | 16h |  |

| ID | WBS | Task | Duration | Start | Finish | Predecessors | Total slack | Free slack | Constraint | Resources | Work |
| --- | --- | --- | --- | --- | --- | --- | --- | --- | --- | --- | --- |
| 31 | 4 | **TM4 HpTa Target Ready for ITE** | 11d | 2016-11-01 08:00 | 2016-11-15 17:00 |  | 12.2d |  |  |  | 88h |
| 32 | 4.1 | HpTa Target Insert into SHC | 0.25d | 2016-11-01 08:00 | 2016-11-01 10:00 | 30 | 18.45d | 0d | start no earlier than 2016-11-01 08:00 | Mjos.A; Fisher.C | 4h |
| 33 | 4.2 | Module Disconnection-TM4-ITE | 0.25d | 2016-11-01 10:00 | 2016-11-01 12:00 | 32 | 18.45d | 0d | start no earlier than 2016-11-01 08:00 | Mcdonald.D; Wang.D | 4h |
| 34 | 4.3 | Module Move-TM4-ITE to SHC | 0.25d | 2016-11-01 13:00 | 2016-11-01 15:00 | 33 | 18.45d | 0.25d | start no earlier than 2016-11-01 08:00 | Wang.D; Cave.T | 4h |
| 35 | 4.4 | New Target Installation/Electrical Check | 0.5d | 2016-11-02 08:00 | 2016-11-02 12:00 | 34 | 18.2d | 0d | start no earlier than 2016-11-02 08:00 | Fisher.C; Cave.T; Wang.D | 12h |
| 36 | 4.5 | Module Move-TM4-SHC to CS/Start of Pumps | 0.5d | 2016-11-02 13:00 | 2016-11-02 17:00 | 35 | 18.2d | 0d | start no earlier than 2016-11-02 08:00 | Cave.T; Wang.D | 8h |
| 37 | 4.6 | Spent Target Move | 1d | 2016-11-03 08:00 | 2016-11-03 17:00 | 36 | 18.2d | 2d | start no earlier than 2016-11-03 08:00 | Fisher.C; Cave.T; Wang.D | 24h |
| 38 | 4.7 | Module Move-TM4-TCS to ITE | 0.5d | 2016-11-08 08:00 | 2016-11-08 12:00 | 37 | 16.2d | 0d | start no earlier than 2016-11-08 08:00 | Cave.T; Wang.D | 8h |
| 39 | 4.8 | Module Connection-TM4-ITE/Start of Pumps | 0.5d | 2016-11-08 13:00 | 2016-11-08 17:00 | 38 | 16.2d | 4d | start no earlier than 2016-11-08 08:00 | Wang.D; Dalla Valle.M | 8h |
| 40 | 4.9 | Shielding Blocks Transfer-ITW to ITE | 1d | 2016-11-15 08:00 | 2016-11-15 17:00 | 39 | 12.2d | 4d | start no earlier than 2016-11-15 08:00 | Wang.D; Mcdonald.D | 16h |
| 41 | 5 | **TM2 Ucx Target Ready for ITW** | 11d | 2016-11-22 08:00 | 2016-12-06 17:00 |  | 0d |  |  |  | 68.8h |
| 42 | 5.1 | UCX Target Insert into SHC | 0.1d | 2016-11-22 08:00 | 2016-11-22 08:48 | 40 | 8.2d | 0d | start no earlier than 2016-11-22 08:00 |  |  |
| 43 | 5.2 | Module Disconnection-TM2-ITW | 0.2d | 2016-11-22 08:48 | 2016-11-22 10:24 | 42 | 8.2d | 0d | start no earlier than 2016-11-22 08:00 | Wang.D; Dalla Valle.M | 3.2h |
| 44 | 5.3 | Module Move-TM2-ITW to SHC | 0.2d | 2016-11-22 10:24 | 2016-11-22 12:00 | 43 | 8.2d | 0d | start no earlier than 2016-11-22 08:00 | Cave.T; Wang.D | 3.2h |
| 45 | 5.4 | New Target Installation/Electrical Check | 0.2d | 2016-11-22 13:00 | 2016-11-22 14:36 | 44 | 8.2d | 0d | start no earlier than 2016-11-22 08:00 | Fisher.C; Cave.T; Wang.D | 4.8h |
| 46 | 5.5 | Module Move-TM2-SHC to CS/Start of Pumps | 0.1d | 2016-11-22 14:36 | 2016-11-22 15:24 | 45 | 8.2d | 0.2d | start no earlier than 2016-11-22 08:00 | Cave.T; Wang.D | 1.6h |
| 47 | 5.6 | Spent Target Move | 1d | 2016-11-23 08:00 | 2016-11-23 17:00 | 46 | 8d | 3d | start no earlier than 2016-11-23 08:00 | Cave.T; Fisher.C; Wang.D | 24h |
| 48 | 5.7 | Module Move-TM2-TCS to ITW | 0.5d | 2016-11-29 08:00 | 2016-11-29 12:00 | 47 | 5d | 0d | start no earlier than 2016-11-29 08:00 | Cave.T; Wang.D | 8h |
| 49 | 5.8 | Module Connection-TM2-ITW/Start of Pumps | 0.5d | 2016-11-29 13:00 | 2016-11-29 17:00 | 48 | 5d |  | start no earlier than 2016-11-29 08:00 | Wang.D; Dalla Valle.M | 8h |
| 50 | 5.9 | Shielding Blocks Transfer-ITE to ITW | 1d | 2016-12-06 08:00 | 2016-12-06 17:00 |  | 0d |  | start no earlier than 2016-12-06 08:00 | Wang.D; Dalla Valle.M | 16h |
